# GD-03 - buitenspouw metselen

Schedule from MS Project, 2003-01-12 to 2003-02-05, status date 2003-01-08.
BAM Nelissen Van Egteren

## Calendars

- ALLEEN WERKDAGEN: Mon-Fri 08:30-12:30, 13:00-17:00; Sat-Sun off. Exceptions (off unless hours are given): 2003-01-11 to 2003-01-12 08:30-12:30, 13:00-17:00, 2003-01-18 to 2003-01-19 08:30-12:30, 13:00-17:00, 2003-01-25 to 2003-01-26 08:30-12:30, 13:00-17:00, 2003-02-01 to 2003-02-02 08:30-12:30, 13:00-17:00.

## Schedule

| ID | WBS | Task | Type | Duration | Start | Finish | Predecessors | Total slack |
| --- | --- | --- | --- | --- | --- | --- | --- | --- |
| 1 | 1 | **GEVEL/DAK FASE** |  | 25d | 2003-01-12 | 2003-02-05 |  | 0d |
| 2 | 1.1 | beg.grond kozijnen+profielen |  | 2d | 2003-01-12 | 2003-01-13 |  | 0d |
| 3 | 1.2 | beg.grond metselen 1e slag |  | 3d | 2003-01-13 | 2003-01-15 | 2SS+1d | 0d |
| 4 | 1.3 | steiger opbouwen vanaf maaiv |  | 2d | 2003-01-15 | 2003-01-16 | 3SS+2d | 0d |
| 5 | 1.4 | beg.grond metselen 2e slag |  | 3d | 2003-01-16 | 2003-01-18 | 4SS+1d | 0d |
| 6 | 1.5 | steiger verder opbouwen |  | 2d | 2003-01-18 | 2003-01-19 | 5SS+2d | 0d |
| 7 | 1.6 | verd. kozijnen+profielen |  | 2d | 2003-01-18 | 2003-01-19 | 6SS | 0d |
| 8 | 1.7 | verd. metselen 3e slag |  | 3d | 2003-01-19 | 2003-01-21 | 7SS+1d | 0d |
| 9 | 1.8 | steiger verder opbouwen |  | 2d | 2003-01-21 | 2003-01-22 | 8SS+2d | 0d |
| 10 | 1.9 | verd. metselen 4e slag |  | 3d | 2003-01-22 | 2003-01-24 | 9SS+1d | 0d |
| 11 | 1.10 | muurplaat+gootbeugels |  | 3d | 2003-01-24 | 2003-01-26 | 10SS+2d | 0d |
| 12 | 1.11 | gordingen+ravelingen |  | 3d | 2003-01-26 | 2003-01-28 | 11SS+2d | 0d |
| 13 | 1.12 | geisoleerde dakplaten |  | 3d | 2003-01-28 | 2003-01-30 | 12SS+2d | 0d |
| 14 | 1.13 | dakpannen+dakrandvoorz. |  | 2d | 2003-01-30 | 2003-01-31 | 13SS+2d | 0d |
| 15 | 1.14 | dakpannen leggen |  | 2d | 2003-02-01 | 2003-02-02 | 14SS+2d | 0d |
| 16 | 1.15 | dakramen+dakdoorvoeren |  | 2d | 2003-02-03 | 2003-02-04 | 15SS+2d | 0d |
| 17 | 1.16 | gevelkozijnen waterdicht |  | 2d | 2003-02-04 | 2003-02-05 | 16SS+1d | 0d |
| 18 | 1.17 | start afbouw fase | milestone | 0d | 2003-02-05 | 2003-02-05 | 17SS+2d | 0d |
